# Cronograma APP Reflorestamento

Schedule from MS Project, 2020-08-27 to 2021-01-26, costs in R$.

## Calendars

- Padrão: Mon-Fri 09:00-12:00, 13:00-18:00; Sat-Sun off. Exceptions (off unless hours are given): 2020-09-07 (Independência do Brasil), 2020-10-12 (Nossa senhora aparecida), 2020-11-02 (Finados), 2020-11-15 (Proclamação da República), 2020-12-25 (Natal).
- Segundas e Quartas: Mon 09:00-12:00, 13:00-18:00; Tue off; Wed 09:00-12:00, 13:00-18:00; Thu-Sun off. Exceptions (off unless hours are given): 2020-09-07 (Independência do Brasil), 2020-10-12 (Nossa senhora aparecida), 2020-11-02 (Finados), 2020-11-15 (Proclamação da República), 2020-12-25 (Natal).

## Resources

| Resource | Rate |
| --- | --- |
| Analista de requisitos | 80 |
| Product Owner | 120 |
| Analista UX | 80 |
| Programador Mobile | 100 |
| Analista de Testes | 75 |
| Gerente de projeto | 150 |
| Programador Backend | 100 |
| Analista UX2 | 80 |
| Celular iOS | 3000 |
| Celular Android | 3000 |

## Schedule

| ID | WBS | Task | Duration | Start | Finish | Predecessors | Baseline start | Baseline finish | Baseline duration | Total slack | Free slack | Calendar | Resources | Work | Cost | Baseline cost |
| --- | --- | --- | --- | --- | --- | --- | --- | --- | --- | --- | --- | --- | --- | --- | --- | --- |
| 1 | 1 | **Requisitos** | 10d | 2020-08-27 | 2020-09-10 |  | 2020-08-27 | 2020-09-10 | 10d | 1d |  |  |  | 240h | 28,000 | 28,000 |
| 2 | 1.1 | Backlog | 10d | 2020-08-27 | 2020-09-10 |  | 2020-08-27 | 2020-09-10 | 10d | 65d | 0d |  | Gerente de projeto; Product Owner | 160h | 21,600 | 21,600 |
| 3 | 1.2 | Detalhar Requisitos | 10d | 2020-08-27 | 2020-09-10 |  | 2020-08-27 | 2020-09-10 | 10d | 1d | 0d |  | Analista de requisitos | 80h | 6,400 | 6,400 |
| 4 | 2 | **Design** | 40d | 2020-09-11 | 2020-11-09 |  | 2020-09-11 | 2020-11-09 | 40d | 1d |  |  |  | 240h | 19,200 | 19,200 |
| 5 | 2.1 | Portal Administrartivo | 15d | 2020-09-14 | 2020-11-09 | 3 | 2020-09-14 | 2020-11-09 | 15d | 0d |  | Segundas e Quartas | Analista UX | 120h | 9,600 | 9,600 |
| 6 | 2.2 | APP | 15d | 2020-09-11 | 2020-10-01 | 3 | 2020-09-11 | 2020-10-01 | 15d | 60d | 0d |  | Analista UX2 | 120h | 9,600 | 9,600 |
| 7 | 3 | **Desenvolvimento** | 55d | 2020-10-02 | 2020-12-21 |  | 2020-10-02 | 2020-12-21 | 55d | 25d |  |  |  | 430h | 43,000 | 43,000 |
| 8 | 3.1 | **Módulos** | 10d | 2020-11-10 | 2020-11-23 |  | 2020-11-10 | 2020-11-23 | 10d | 0d |  |  |  | 30h | 3,000 | 3,000 |
| 9 | 3.1.1 | Login | 2d | 2020-11-10 | 2020-11-11 | 5 | 2020-11-10 | 2020-11-11 | 2d | 0d |  |  | Programador Backend | 8h | 800 | 800 |
| 10 | 3.1.2 | Manter Cadastro | 4d | 2020-11-12 | 2020-11-17 | 9 | 2020-11-12 | 2020-11-17 | 4d | 0d |  |  | Programador Backend | 14h | 1,400 | 1,400 |
| 11 | 3.1.3 | Consulta / Detalhes | 2d | 2020-11-18 | 2020-11-19 | 10 | 2020-11-18 | 2020-11-19 | 2d | 0d |  |  | Programador Backend | 4h | 400 | 400 |
| 12 | 3.1.4 | Relatório | 2d | 2020-11-20 | 2020-11-23 | 11 | 2020-11-20 | 2020-11-23 | 2d | 0d |  |  | Programador Backend | 4h | 400 | 400 |
| 13 | 3.2 | **Interface** | 20d | 2020-10-02 | 2020-10-30 |  | 2020-10-02 | 2020-10-30 | 20d | 60d |  |  |  | 160h | 16,000 | 16,000 |
| 14 | 3.2.1 | Login | 5d | 2020-10-02 | 2020-10-08 | 6 | 2020-10-02 | 2020-10-08 | 5d | 60d | 0d |  | Programador Mobile | 40h | 4,000 | 4,000 |
| 15 | 3.2.2 | Cadastro | 5d | 2020-10-09 | 2020-10-16 | 14 | 2020-10-09 | 2020-10-16 | 5d | 60d | 0d |  | Programador Mobile | 40h | 4,000 | 4,000 |
| 16 | 3.2.3 | Apontar Localidade | 5d | 2020-10-19 | 2020-10-23 | 15 | 2020-10-19 | 2020-10-23 | 5d | 60d | 0d |  | Programador Mobile | 40h | 4,000 | 4,000 |
| 17 | 3.2.4 | Feedback | 5d | 2020-10-26 | 2020-10-30 | 16 | 2020-10-26 | 2020-10-30 | 5d | 60d |  |  | Programador Mobile | 40h | 4,000 | 4,000 |
| 18 | 3.3 | Codificação | 30d | 2020-11-10 | 2020-12-21 | 8SS | 2020-11-10 | 2020-12-21 | 30d | 5d | 0d |  | Programador Backend; Programador Mobile | 240h | 24,000 | 24,000 |
| 19 | 4 | **Testes** | 45d | 2020-11-17 | 2021-01-19 |  | 2020-11-17 | 2021-01-19 | 45d | 5d |  |  |  | 800h | 99,000 | 99,000 |
| 20 | 4.1 | Testes Unitários | 30d | 2020-11-17 | 2020-12-29 | 18SS+5d | 2020-11-17 | 2020-12-29 | 30d | 5d | 0d |  | Programador Backend; Programador Mobile | 240h | 24,000 | 24,000 |
| 21 | 4.2 | Testes Integrados | 25d | 2020-11-24 | 2020-12-29 | 8 | 2020-11-24 | 2020-12-29 | 25d | 0d |  |  | Analista de Testes; Celular iOS; Celular Android | 200h | 21,000 | 21,000 |
| 22 | 4.3 | Relatório de Testes | 45d | 2020-11-17 | 2021-01-19 | 20SS | 2020-11-17 | 2021-01-19 | 45d | 5d |  |  | Gerente de projeto | 360h | 54,000 | 54,000 |
| 23 | 5 | **Implantação** | 90d | 2020-09-11 | 2021-01-19 |  | 2020-09-11 | 2021-01-19 | 90d | 0d |  |  |  | 280h | 30,400 | 30,400 |
| 24 | 5.1 | Cadastramento nas lojas | 10d | 2020-09-11 | 2020-09-24 | 2 | 2020-09-11 | 2020-09-24 | 10d | 65d |  |  | Product Owner | 80h | 9,600 | 9,600 |
| 25 | 5.2 | Versão Controlada (Beta) | 10d | 2020-12-30 | 2021-01-12 | 24, 21 | 2020-12-30 | 2021-01-12 | 10d | 0d |  |  | Programador Backend; Programador Mobile | 160h | 16,000 | 16,000 |
| 26 | 5.3 | Treinamento | 5d | 2021-01-13 | 2021-01-19 | 2, 24, 25 | 2021-01-13 | 2021-01-19 | 5d | 0d |  |  | Product Owner | 40h | 4,800 | 4,800 |
| 27 | 6 | Go Live | 5d | 2021-01-20 | 2021-01-26 | 26 | 2021-01-20 | 2021-01-26 | 5d | 0d |  |  | Gerente de projeto; Product Owner | 80h | 10,800 | 10,800 |
